# HDF Java

Schedule from MS Project, 2001-05-01 to 2002-04-26, A marks actual dates.
NCSA

## Calendars

- Standard: Mon-Fri 08:00-12:00, 13:00-17:00; Sat-Sun off.

## Schedule

| ID | WBS | Task | Type | Duration | Start | Finish | Predecessors | Complete | Remaining | Total slack | Free slack | Constraint |
| --- | --- | --- | --- | --- | --- | --- | --- | --- | --- | --- | --- | --- |
| 1 | 1 | **H5View 2.2** |  | 99d | 2001-05-01 A | 2001-09-14 |  | 13% | 86.47d | 160d |  |  |
| 2 | 1.1 | **Bugs** |  | 1d | 2001-05-01 A | 2001-05-01 |  | 80% | 0.2d | 9d | 0d |  |
| 3 | 1.1.1 | palette with negative values? |  | 1d | 2001-05-01 A | 2001-05-01 A |  | 100% |  |  |  |  |
| 4 | 1.1.2 | default iconPath |  | 1d | 2001-05-01 A | 2001-05-01 A | 3 | 100% |  |  |  |  |
| 5 | 1.1.3 | Deleted 'save 7 pack' option: unfixable bug on windows |  | 1d | 2001-05-01 A | 2001-05-01 A | 4 | 100% |  |  |  |  |
| 6 | 1.1.4 | bug when default pal is used |  | 1d | 2001-05-01 A | 2001-05-01 A | 5 | 100% |  |  |  |  |
| 7 | 1.1.5 | Fix bug in looking for default browser |  | 1d | 2001-05-01 | 2001-05-01 |  |  |  | 9d |  |  |
| 8 | 1.2 | **Features** |  | 32d | 2001-05-02 A | 2001-06-14 | 2 | 14% | 27.64d | 46d | 0d |  |
| 9 | 1.2.1 | Save image as JPEG |  | 1d | 2001-05-15 A | 2001-05-15 A |  | 100% |  |  |  |  |
| 10 | 1.2.2 | save selection from image as JPEG |  | 1d | 2001-05-15 A | 2001-05-15 A | 9 | 100% |  |  |  |  |
| 11 | 1.2.3 | port to JDK 1.3_02 |  | 1d | 2001-05-15 A | 2001-05-16 A | 10 | 100% |  |  |  |  |
| 12 | 1.2.4 | save all or part of dataset as tab delimited text filr |  | 1d | 2001-05-15 A | 2001-05-15 A | 11 | 100% |  |  |  |  |
| 13 | 1.2.5 | Row/columen selection in spreadsheet |  | 1d | 2001-05-15 A | 2001-05-15 A | 12 | 100% |  |  |  |  |
| 14 | 1.2.6 | View data as spreadsheet or image |  | 1d | 2001-05-16 A | 2001-05-16 A | 13 | 100% |  |  |  |  |
| 15 | 1.2.7 | Design review for all new features | milestone | 1d | 2001-06-07 | 2001-06-07 |  |  |  | 51d |  | start no earlier than 2001-06-07 |
| 16 | 1.2.8 | User preferences and history |  | 5d | 2001-05-02 | 2001-05-08 |  |  |  | 46d | 0d |  |
| 17 | 1.2.9 | Redesign Attribute dialogs |  | 5d | 2001-05-09 | 2001-05-15 | 16 |  |  | 46d | 0d |  |
| 18 | 1.2.10 | Redesign other GUI |  | 2d | 2001-05-16 | 2001-05-17 | 17 |  |  | 46d | 0d |  |
| 19 | 1.2.11 | X-Y plot of data in a spreadsheet column |  | 5d | 2001-05-18 | 2001-05-24 | 18 |  |  | 46d | 0d |  |
| 20 | 1.2.12 | Histogram, cross-line plot for image |  | 5d | 2001-05-25 | 2001-05-31 | 19 |  |  | 46d | 0d |  |
| 21 | 1.2.13 | Display palette in graph as separate RGB lines |  | 2d | 2001-06-01 | 2001-06-04 | 20 |  |  | 46d | 0d |  |
| 22 | 1.2.14 | optional default palette, such as Rainbow |  | 1d | 2001-06-05 | 2001-06-05 | 21 |  |  | 46d | 0d |  |
| 23 | 1.2.15 | Modify image palette and apply the new palette |  | 5d | 2001-06-06 | 2001-06-12 | 22 |  |  | 46d | 0d |  |
| 24 | 1.2.16 | Modify data range for image display |  | 2d | 2001-06-13 | 2001-06-14 | 23 |  |  | 46d |  |  |
| 25 | 1.2.17 | Simple math computation, a la visicalc |  | 5d | 2001-05-02 | 2001-05-08 |  |  |  | 73d |  |  |
| 26 | 1.3 | Testing |  | 10d | 2001-06-15 | 2001-06-28 | 8 |  |  | 216d |  |  |
| 27 | 1.4 | Documentation |  | 10d | 2001-06-15 | 2001-06-28 | 8 |  |  | 46d |  |  |
| 28 | 1.5 | Release | milestone | 10d | 2001-09-03 | 2001-09-14 | 27 |  |  | 0d |  | must finish on 2001-09-14 |
| 30 | 2 | EOS Workshop | milestone | 3d | 2001-09-19 | 2001-09-21 |  |  |  | 155d |  | start no earlier than 2001-09-19 |

| ID | WBS | Task | Type | Duration | Start | Finish | Predecessors | Total slack | Constraint |
| --- | --- | --- | --- | --- | --- | --- | --- | --- | --- |
| 31 | 3 | **H5V 3.0 (phase out JHV)** |  | 150d | 2001-10-01 | 2002-04-26 |  | 0d |  |
| 32 | 3.1 | Design phase |  | 60d | 2001-10-01 | 2001-12-21 |  | 0d | start no earlier than 2001-10-01 |
| 33 | 3.2 | Implement |  | 40d | 2001-12-24 | 2002-02-15 | 32 | 0d |  |
| 34 | 3.3 | Document |  | 30d | 2002-02-18 | 2002-03-29 | 33 | 0d |  |
| 35 | 3.4 | Release (JHV is obsolete) | milestone | 20d | 2002-04-01 | 2002-04-26 | 34 | 0d |  |
